# Leccion 1-1

How a schedule from MS Project changed from version to version. A marks actual dates.

## Version 1 (saved 2007-10-30, file Leccion 1-1.mpp)

| ID | WBS | Task | Duration | Start | Finish | Predecessors | Total float |
| --- | --- | --- | --- | --- | --- | --- | --- |
| 1 |  | Replantaer cimientos | 1d | 2007-10-26 | 2007-10-29 |  | 0d |
| 2 |  | Excavar zanjas | 2d | 2007-10-29 | 2007-10-31 | 1 | 0d |
| 3 |  | Preparar armaduras | 4d | 2007-10-26 | 2007-11-01 |  | 0d |
| 4 | 4 | **Preparar moldes** | 3d | 2007-10-29 | 2007-11-01 |  | 0d |
| 5 |  | Preparar tableros | 2d | 2007-10-29 | 2007-10-31 | 1, 2SS | 0d |
| 6 |  | Colocar tableros | 1d | 2007-10-31 | 2007-11-01 | 5, 2 | 0d |
| 7 |  | Colocar armaduras | 2d | 2007-11-01 | 2007-11-05 | 3, 6 | 0d |
| 8 |  | Colar hormigón | 1d | 2007-11-05 | 2007-11-06 | 7 | 0d |

## Version 2 (saved 2007-11-03, file Leccion 1-1 - 1.mpp)

Last finish stays 2007-11-06.

Changed:

| ID | Task | Start | Duration | Predecessors | Other |
| --- | --- | --- | --- | --- | --- |
| 1 | Replantear cimientos | 2007-10-26 → 2007-10-29 (+3d) | 1d → 0.9d |  | was named Replantaer cimientos |
| 2 | Excavar zanjas |  | 2d → 1.8d |  |  |
| 3 | Preparar armaduras | 2007-10-26 → 2007-10-29 (+3d) | 4d → 3.6d |  |  |
| 4 | **Preparar moldes** |  | 3d → 2.7d |  |  |
| 5 | Preparar tableros |  | 2d → 1.8d | 1, 2SS → 2SS |  |
| 6 | Colocar tableros |  | 1d → 0.9d |  |  |
| 7 | Colocar armaduras |  | 2d → 1.8d |  |  |
| 8 | Colar hormigón |  | 1d → 0.9d |  |  |

## Version 3 (saved 2007-11-10, file Leccion 1-1 - 2.mpp)

Last finish 2007-11-06 → 2009-01-30 (+451d).

Added:

| ID | Task | Duration | Start | Finish | Predecessors |
| --- | --- | --- | --- | --- | --- |
| 9 | Imprevistos | 1mo | 2008-12-31 | 2009-01-30 | 8 |

Changed:

| ID | Task | Start | Finish | Duration | Total float | Predecessors | Other |
| --- | --- | --- | --- | --- | --- | --- | --- |
| 1 | Replantear cimientos | 2007-10-29 → 2007-10-26 (-3d) | 2007-10-29 → 2007-11-27 (+29d) | 0.9d → 1mo | 0d → 107.33d |  | resources none → Oficial |
| 2 | Excavar zanjas | 2007-10-29 → 2007-11-27 (+29d) | 2007-10-31 → 2007-12-14 (+44d) | 1.8d → 0.6mo | 0d → 135.33d |  | resources none → Ayudante [1000%] |
| 3 | Preparar armaduras | 2007-10-29 → 2008-06-24 (+239d) | 2007-11-01 → 2008-08-28 (+301d) | 3.6d → 2.09mo |  |  | constraint none → as late as possible; resources none → Oficial [239.2%]; Ayudante [119.6%] |
| 4 | **Preparar moldes** | 2007-10-29 → 2007-12-17 (+49d) | 2007-11-01 → 2008-07-09 (+251d) | 2.7d → 130.22d | 0d → 25.11d |  |  |
| 5 | Preparar tableros | 2007-10-29 → 2007-12-17 (+49d) | 2007-10-31 → 2008-02-15 (+107d) | 1.8d → 2mo | 0d → 95.33d | 2SS → 1, 2SS | constraint none → start no earlier than 2007-12-17; resources none → Oficial |
| 6 | Colocar tableros | 2007-10-31 → 2008-06-09 (+222d) | 2007-11-01 → 2008-07-09 (+251d) | 0.9d → 1mo | 0d → 25.11d |  | constraint none → start no earlier than 2008-06-09; resources none → Oficial |
| 7 | Colocar armaduras | 2007-11-01 → 2008-08-08 (+281d) | 2007-11-05 → 2008-11-11 (+372d) | 1.8d → 3mo |  | 3, 6 → 3SS+7%, 6SS+7% |  |
| 8 | Colar hormigón | 2007-11-05 → 2008-11-11 (+372d) | 2007-11-06 → 2008-12-31 (+421d) | 0.9d → 1.6mo |  |  | resources none → Oficial [125%]; Cemento [125000%]; Arena [25800%] |

## Version 4 (saved 2007-12-01, file Leccion 1-1 - 3.mpp)

Last finish 2009-01-30 → 2009-02-05 (+6d). Complete tasks 0 → 6.

Changed:

| ID | Task | Start | Finish | Duration | Complete | Total float | Other |
| --- | --- | --- | --- | --- | --- | --- | --- |
| 1 | Replantear cimientos | 2007-10-26 A | 2007-11-27 A |  | 0% → 100% | 107.33d → none | baseline start none → 2007-10-26; baseline finish none → 2007-11-27 |
| 2 | Excavar zanjas | 2007-11-27 A | 2007-12-14 A |  | 0% → 100% | 135.33d → none | baseline start none → 2007-11-27; baseline finish none → 2007-12-14 |
| 3 | Preparar armaduras | 2008-06-24 → 2008-07-01 A (+7d) | 2008-08-28 → 2008-09-01 A (+4d) | 2.09mo → 2mo | 0% → 100% | 0d → none | resources Oficial [239.2%]; Ayudante [119.6%] → Oficial [250%]; Ayudante [125%]; baseline start none → 2008-06-24; baseline finish none → 2008-08-28 |
| 4 | **Preparar moldes** | 2007-12-17 A | 2008-07-09 A |  | 0% → 100% | 25.11d → none | baseline start none → 2007-12-17; baseline finish none → 2008-07-09 |
| 5 | Preparar tableros | 2007-12-17 A | 2008-02-15 A |  | 0% → 100% | 95.33d → none | baseline start none → 2007-12-17; baseline finish none → 2008-02-15 |
| 6 | Colocar tableros | 2008-06-09 A | 2008-07-09 A |  | 0% → 100% | 25.11d → none | baseline start none → 2008-06-09; baseline finish none → 2008-07-09 |
| 7 | Colocar armaduras | 2008-08-08 → 2008-08-13 A (+5d) | 2008-11-11 → 2008-11-14 A (+3d) |  | 0% → 100% | 0d → none | resources none → Oficial [200%]; Ayudante [200%]; baseline start none → 2008-08-08; baseline finish none → 2008-11-11 |
| 8 | Colar hormigón | 2008-11-11 → 2008-11-17 (+6d) | 2008-12-31 → 2009-01-05 (+5d) |  |  | 0d → -3.11d | baseline start none → 2008-11-11; baseline finish none → 2008-12-31 |
| 9 | Imprevistos | 2008-12-31 → 2009-01-06 (+6d) | 2009-01-30 → 2009-02-05 (+6d) |  |  | 0d → -3.11d | baseline start none → 2008-12-31; baseline finish none → 2009-01-30 |
